# 2-2

Schedule from MS Project, 2023-09-07 to 2024-03-29, 2 hours a day, costs in €, A marks actual dates.
Universite Clermont Auvergne

## Calendars

- SAE: Mon 08:00-10:00, 13:30-17:30; Tue 08:00-10:00; Wed 08:00-10:00, 13:30-16:30; Thu 08:00-10:00; Fri 08:00-10:00, 13:30-16:30; Sat-Sun off. Exceptions (off unless hours are given): 2023-11-20 to 2023-11-26 08:00-12:00, 13:30-16:30, 2024-01-03 to 2024-01-07 08:00-10:00, 13:30-16:30, 2024-01-08 to 2024-01-13 08:00-10:00, 13:30-17:30, 2024-03-25 to 2024-04-03 08:00-12:00, 13:30-16:30.

## Resources

| Resource | Rate |
| --- | --- |
| A_PE | 20 |
| K_MO | 20 |
| P_LE | 20 |
| D_DA | 20 |
| A_PI | 20 |

## Schedule

| ID | WBS | Task | Duration | Start | Finish | Predecessors | Complete | Remaining | Baseline start | Baseline finish | Baseline duration | Total slack | Free slack | Constraint | Resources | Work | Actual work | Cost | Baseline cost | Actual cost |
| --- | --- | --- | --- | --- | --- | --- | --- | --- | --- | --- | --- | --- | --- | --- | --- | --- | --- | --- | --- | --- |
| 1 | 1 | **Étude de courbes de fréquence cardiaque** | 329.5d | 2023-09-07 A | 2024-03-29 |  | 37% | 206.69d | 2023-09-15 | 2024-04-04 | 144.83d | 0d |  |  |  | 300.49h | 77.59h | 6,009.87 | 11,159.78 | 1,551.9 |
| 2 | 1.1 | **1 - Management de projet** | 40.5d | 2024-03-07 | 2024-03-29 |  |  |  | 2023-09-15 | 2024-04-04 | 144.83d | 0d |  |  |  | 70h |  | 1,400 | 3,320 |  |
| 3 | 1.1.1 | **1.4 - Suivi de projet** | 40.5d | 2024-03-07 | 2024-03-29 |  |  |  | 2023-10-12 | 2024-04-04 | 125.58d | 0d |  |  |  | 70h |  | 1,400 | 1,180 |  |
| 4 | 1.1.1.1 | 1.4.4 - Préparation des rapports globaux | 8h | 2024-03-07 | 2024-03-11 |  |  |  |  |  |  | 36.54d | 33.5d | start no earlier than 2024-03-07 | A_PE; A_PI; D_DA; K_MO; P_LE | 40h |  | 800 |  |  |
| 5 | 1.1.1.2 | 1.4.5 - Préparation des vidéos | 6h | 2024-03-29 | 2024-03-29 | 4 |  |  |  |  |  | 0d |  | start no earlier than 2024-03-29 | A_PE; A_PI; D_DA; K_MO; P_LE | 30h |  | 600 |  |  |
| 6 | 1.2 | **2 - Développement** | 314.5d | 2023-09-07 A | 2024-03-25 |  | 40% | 187.84d | 2023-09-20 | 2024-02-26 | 112.75d | 15d |  |  |  | 230.49h | 77.59h | 4,609.87 | 7,839.78 | 1,551.9 |
| 7 | 1.2.1 | **2.1 - Conception** | 292.5d | 2023-09-07 A | 2024-03-08 |  | 52% | 139.5d | 2023-09-20 | 2023-12-15 | 62.1d | 37d |  |  |  | 13h | 6.8h | 260 | 1,544.62 | 136 |
| 8 | 1.2.1.1 | 2.1.1 - Communication (reseaux) | 7h | 2024-03-07 A | 2024-03-08 |  | 80% | 1.4h | 2023-11-15 | 2023-12-15 | 7h | 0d |  |  | A_PE; P_LE | 7h | 5.6h | 140 | 140 | 112 |
| 9 | 1.2.1.2 | 2.1.8 - Maquettes Kotlin | 6h | 2023-09-07 A | 2023-09-11 |  | 20% | 4.8h |  |  |  | 325d |  |  | A_PI | 6h | 1.2h | 120 |  | 24 |
| 10 | 1.2.2 | **2.2 - Client Web** | 7.5d | 2024-03-07 A | 2024-03-12 |  | 79% | 1.61d | 2023-11-15 | 2024-02-05 | 58.14d | 33d |  |  |  | 21h | 16.5h | 420 | 2,937.27 | 330 |
| 11 | 1.2.2.1 | 2.2.1 - Interface utilisateur client (Vues) WEB | 15h | 2024-03-07 A | 2024-03-12 |  | 90% | 1.5h | 2023-11-20 | 2024-01-09 | 15h | 33d |  |  | A_PI | 15h | 13.5h | 300 | 300 | 270 |
| 12 | 1.2.2.2 | 2.2.6 - Définitions des algoritmes d'analyse de la fréquence cardiaque | 6h | 2024-03-07 A | 2024-03-08 |  | 50% | 3h | 2023-12-15 | 2023-12-22 | 0h | 37.5d |  | start no earlier than 2024-01-29 | D_DA; A_PE | 6h | 3h | 120 |  | 60 |
| 13 | 1.2.3 | **2.3 - Web admin et monitorin** | 7.25d | 2024-03-07 | 2024-03-12 |  |  |  | 2023-11-22 | 2024-01-01 | 27.38d | 0d |  |  |  | 23.77h |  | 475.33 | 465.57 |  |
| 14 | 1.2.3.1 | 2.3.1 - Authentification admin et monitoring | 10.9h | 2024-03-07 | 2024-03-11 |  |  |  | 2023-12-25 | 2024-01-01 | 9.51h | 1.8d |  | start no earlier than 2024-03-07 | A_PE; D_DA | 13.77h |  | 275.33 | 265.57 |  |
| 15 | 1.2.3.2 | 2.3.2 - Interface utilisateur admin (Vues) | 10h | 2024-03-07 | 2024-03-12 |  |  |  | 2023-11-22 | 2023-12-01 | 10h | 0d |  | start no earlier than 2024-03-07 | A_PI | 10h |  | 200 | 200 |  |
| 16 | 1.2.4 | **2.6 - Integration continue et livraison continue (CI/ CD)** | 25.5d | 2024-03-07 A | 2024-03-25 |  | 45% | 13.96d | 2023-11-15 | 2024-02-26 | 72.66d | 15d |  |  |  | 114.69h | 47.64h | 2,293.73 | 1,480 | 952.8 |
| 17 | 1.2.4.1 | 2.6.1 - Tests - PHP | 15.4h | 2024-03-07 A | 2024-03-13 |  | 80% | 3.08h | 2023-11-15 | 2024-01-23 | 40h | 7.8d | 2.3d |  | A_PE; A_PI; D_DA; K_MO; P_LE | 24.6h | 17.64h | 492 | 960 | 352.8 |
| 18 | 1.2.4.2 | 2.6.2 - Tests | 30h | 2024-03-14 A | 2024-03-25 | 17 | 40% | 18h |  |  |  | 15d |  | start no earlier than 2024-02-12 |  |  |  |  |  |  |
| 19 | 1.2.4.3 | 2.6.3 - Conteneurisation et déploiementc - PHP | 10h | 2024-03-07 A | 2024-03-11 |  | 90% | 1h | 2023-11-15 | 2024-01-23 | 8h | 8.5d | 5.5d |  | A_PE; D_DA | 10h | 9h | 200 | 160 | 180 |
| 20 | 1.2.4.4 | 2.6.4 - Conteneurisation et deploiement | 19h | 2024-03-14 A | 2024-03-21 | 19 | 32% | 13h |  |  |  | 19.5d |  | start no earlier than 2024-02-05 | A_PE; D_DA | 19h | 6h | 380 |  | 120 |
| 21 | 1.2.4.5 | 2.6.5 - Documentations (swagger, schéma, …) PHP | 10h | 2024-03-18 A | 2024-03-20 | 17 | 50% | 5h | 2024-01-23 | 2024-02-26 | 6h | 15.23d | 0d |  | A_PE; A_PI; D_DA | 30h | 15h | 600 | 360 | 300 |
| 22 | 1.2.4.6 | 2.6.6 - Documentations | 13.54h | 2024-03-20 | 2024-03-25 | 21 |  |  |  |  |  | 15.23d |  |  | D_DA; K_MO; P_LE | 31.09h |  | 621.73 |  |  |
| 23 | 1.2.5 | **2.7 - Base de donnée et API** | 4.35d | 2024-03-07 A | 2024-03-11 |  | 15% | 3.7d |  |  |  | 36.15d |  |  |  | 4h | 0.6h | 80 |  | 12 |
| 24 | 1.2.5.1 | 2.7.4 - Liaison des Entities et de l'API | 2h | 2024-03-07 A | 2024-03-11 | 8 | 15% | 1.7h |  |  |  | 36.15d |  |  | D_DA; A_PI | 4h | 0.6h | 80 |  | 12 |

| ID | WBS | Task | Duration | Start | Finish | Predecessors | Complete | Remaining | Total slack | Free slack | Constraint | Resources | Work | Actual work | Cost | Actual cost |
| --- | --- | --- | --- | --- | --- | --- | --- | --- | --- | --- | --- | --- | --- | --- | --- | --- |
| 25 | 1.2.6 | **2.8 - Application Mobile** | 24.25d | 2024-03-07 A | 2024-03-25 |  | 11% | 21.65d | 16.25d |  |  |  | 54.04h | 6.05h | 1,080.8 | 121.1 |
| 26 | 1.2.6.1 | 2.8.1 - Définitions de l'architecture Kotlin | 4.8h | 2024-03-07 A | 2024-03-13 | 13 | 17% | 3.98h | 8.86d | 0d | start no earlier than 2024-02-05 | A_PI; D_DA | 4.8h | 0.81h | 96 | 16.3 |
| 27 | 1.2.6.2 | 2.8.2 - Interface utilisateur (vues) Mobile | 1d | 2024-03-13 | 2024-03-14 | 26 |  |  | 27.51d | 11.26d |  | A_PI | 2h |  | 40 |  |
| 28 | 1.2.6.3 | 2.8.3 - Diagramme de classes Kotlin | 8h | 2024-03-20 A | 2024-03-22 | 26 | 15% | 6.8h | 16.25d | 0d |  | A_PE; A_PI; D_DA; K_MO; P_LE | 39.24h | 5.24h | 784.8 | 104.8 |
| 29 | 1.2.6.4 | 2.8.4 - Authentification client Mobile | 4h | 2024-03-22 | 2024-03-25 | 27, 28 |  |  | 16.25d |  |  | D_DA; K_MO; P_LE | 8h |  | 160 |  |
