# 2-2

Schedule from MS Project, 2023-09-15 to 2024-04-07, 2 hours a day, costs in €, A marks actual dates.
Universite Clermont Auvergne

## Calendars

- SAE: Mon 08:00-10:00, 13:30-17:30; Tue 08:00-10:00; Wed 08:00-10:00, 13:30-16:30; Thu 08:00-10:00; Fri 08:00-10:00, 13:30-16:30; Sat-Sun off. Exceptions (off unless hours are given): 2023-11-20 to 2023-11-26 08:00-12:00, 13:30-16:30, 2024-01-03 to 2024-01-07 08:00-10:00, 13:30-16:30, 2024-01-08 to 2024-01-13 08:00-10:00, 13:30-17:30, 2024-03-25 to 2024-04-03 08:00-12:00, 13:30-16:30.

## Resources

| Resource | Rate |
| --- | --- |
| A_PE | 20 |
| K_MO | 20 |
| P_LE | 20 |
| D_DA | 20 |
| A_PI | 20 |

## Schedule

| ID | WBS | Task | Duration | Start | Finish | Predecessors | Complete | Actual finish | Baseline start | Baseline finish | Baseline duration | Constraint | Resources | Work | Actual work | Cost | Baseline cost | Actual cost |
| --- | --- | --- | --- | --- | --- | --- | --- | --- | --- | --- | --- | --- | --- | --- | --- | --- | --- | --- |
| 1 | 1 | **Étude de courbes de fréquence cardiaque** | 340d | 2023-09-15 A | 2024-04-07 |  | 100% | 2024-04-02 | 2023-09-15 | 2024-04-04 | 144.83d |  |  | 904.35h | 904.35h | 18,086.93 | 11,159.78 | 18,086.93 |
| 2 | 1.1 | **1 - Management de projet** | 306.9d | 2023-09-15 A | 2024-03-26 A |  | 100% |  | 2023-09-15 | 2024-04-04 | 144.83d |  |  | 275.73h | 275.73h | 5,514.67 | 3,320 | 5,514.67 |
| 3 | 1.1.1 | **1.1 - Recueil de besoins** | 293.86d | 2023-09-15 A | 2024-03-18 A |  | 100% |  | 2023-09-15 | 2023-10-16 | 21.75d |  |  | 111.72h | 111.72h | 2,234.3 | 1,500 | 2,234.3 |
| 4 | 1.1.1.1 | 1.1.1 - Présentation general du projet | 2h | 2023-09-20 A | 2023-09-21 A | 11 | 100% |  | 2023-09-20 | 2023-09-21 | 2h |  | A_PE | 2h | 2h | 40 | 40 | 40 |
| 5 | 1.1.1.2 | 1.1.2 - Compte rendu 1 | 3h | 2023-09-21 A | 2023-09-25 A | 4, 9 | 100% |  | 2023-09-21 | 2023-09-25 | 3h |  | A_PE; A_PI; D_DA; K_MO; P_LE | 7h | 7h | 140 | 140 | 140 |
| 6 | 1.1.1.3 | 1.1.3 - Compte rendu 2 | 14h | 2023-09-28 A | 2023-10-13 A | 7 | 100% |  | 2023-09-28 | 2023-10-13 | 14h |  | A_PE; A_PI; D_DA; K_MO; P_LE | 25h | 25h | 500 | 500 | 500 |
| 7 | 1.1.1.4 | 1.1.4 - Backlog (users stories) | 5h | 2023-09-25 A | 2023-09-28 A | 5 | 100% |  | 2023-09-25 | 2023-09-28 | 5h |  | D_DA; P_LE | 10h | 10h | 200 | 200 | 200 |
| 8 | 1.1.1.5 | **1.1.5 - Rendez vous** | 293.86d | 2023-09-15 A | 2024-03-18 A |  | 100% |  | 2023-09-15 | 2023-09-21 | 4.75d |  |  | 42.72h | 42.72h | 854.3 | 420 | 854.3 |
| 9 | 1.1.1.5.1 | 1.1.5.1 - Avec le tuteur - 15/12/2023 | 12h | 2023-09-15 A | 2023-09-22 A |  | 100% |  | 2023-09-15 | 2023-09-21 | 6.5h | finish no earlier than 2024-03-07 | A_PE; A_PI; D_DA; K_MO; P_LE | 21.5h | 21.5h | 430 | 320 | 430 |
| 10 | 1.1.1.5.2 | 1.1.5.2 - Avec le tuteur | 6h | 2024-03-05 A | 2024-03-15 A | 28 | 100% |  |  |  |  | start no earlier than 2024-03-05 | A_PE; A_PI; D_DA; K_MO; P_LE | 6h | 6h | 120 |  | 120 |
| 11 | 1.1.1.5.3 | 1.1.5.3 - Avec le client - 15/12/2023 | 7h | 2023-09-15 A | 2023-09-18 A |  | 100% |  | 2023-09-15 | 2023-09-20 | 4h | finish no earlier than 2024-03-07 | A_PE; A_PI; D_DA; K_MO; P_LE | 8h | 8h | 160 | 100 | 160 |
| 12 | 1.1.1.5.4 | 1.1.5.4 - Avec le client | 7h | 2024-03-11 A | 2024-03-18 A | 28 | 100% |  |  |  |  | start no earlier than 2024-03-11 | A_PE; A_PI; D_DA; K_MO; P_LE | 7.21h | 7.21h | 144.3 |  | 144.3 |
| 13 | 1.1.1.6 | 1.1.6 - Rapport BDD | 6.7h | 2023-10-09 A | 2023-10-16 A | 42 | 100% |  | 2023-10-09 | 2023-10-16 | 6h |  | A_PE; P_LE; D_DA; K_MO; A_PI | 10h | 10h | 200 | 200 | 200 |
| 14 | 1.1.1.7 | 1.1.7 - Compte rendu 1 (v2) | 8h | 2023-09-25 A | 2023-09-29 A | 5 | 100% |  |  |  |  |  | A_PE | 8h | 8h | 160 |  | 160 |
| 15 | 1.1.1.8 | 1.1.8 - Compte rendu 2 (v2) | 7h | 2023-10-13 A | 2023-10-15 A | 6 | 100% |  |  |  |  |  | A_PE | 7h | 7h | 140 |  | 140 |
| 16 | 1.1.2 | **1.2 - Organisation du travail en équipe** | 20.75d | 2023-09-15 A | 2023-09-29 A |  | 100% |  | 2023-09-15 | 2023-09-29 | 10.75d |  |  | 8h | 8h | 160 | 160 | 160 |
| 17 | 1.1.2.1 | 1.2.1 - Mise en place du kanban | 2h | 2023-09-15 A | 2023-09-28 A |  | 100% |  | 2023-09-15 | 2023-09-28 | 2h |  | A_PE; D_DA | 2h | 2h | 40 | 40 | 40 |
| 18 | 1.1.2.2 | 1.2.2 - Mise en place du codefirst | 3h | 2023-09-28 A | 2023-09-29 A |  | 100% |  | 2023-09-28 | 2023-09-29 | 3h |  | D_DA | 3h | 3h | 60 | 60 | 60 |
| 19 | 1.1.2.3 | 1.2.3 - Mise en place du notion | 2h | 2023-09-15 A | 2023-09-19 A |  | 100% |  | 2023-09-15 | 2023-09-19 | 2h |  | D_DA; A_PE | 2h | 2h | 40 | 40 | 40 |
| 20 | 1.1.2.4 | 1.2.4 - Mise en place du discord | 0.5h | 2023-09-15 A | 2023-09-15 A |  | 100% |  | 2023-09-15 | 2023-09-15 | 0.5h |  | A_PE; A_PI | 1h | 1h | 20 | 20 | 20 |
| 21 | 1.1.3 | **1.3 - Planification du projet** | 26d | 2023-09-25 A | 2023-10-12 A |  | 100% |  | 2023-09-25 | 2023-10-12 | 12.5d |  |  | 24h | 24h | 480 | 480 | 480 |
| 22 | 1.1.3.1 | 1.3.1 - WBS | 6.5h | 2023-09-25 A | 2023-09-29 A | 5 | 100% |  | 2023-09-25 | 2023-09-29 | 6.5h |  | A_PE; K_MO | 10h | 10h | 200 | 200 | 200 |
| 23 | 1.1.3.2 | 1.3.2 - GANTT prévisionnel | 10h | 2023-09-29 A | 2023-10-10 A | 22 | 100% |  | 2023-09-29 | 2023-10-10 | 10h |  | A_PE; P_LE | 10h | 10h | 200 | 200 | 200 |
| 24 | 1.1.3.3 | 1.3.3 - PERT | 4h | 2023-10-10 A | 2023-10-12 A | 23 | 100% |  | 2023-10-10 | 2023-10-12 | 4h |  | A_PE; P_LE | 4h | 4h | 80 | 80 | 80 |

| ID | WBS | Task | Duration | Start | Finish | Predecessors | Complete | Actual finish | Baseline start | Baseline finish | Baseline duration | Constraint | Resources | Work | Actual work | Cost | Baseline cost | Actual cost |
| --- | --- | --- | --- | --- | --- | --- | --- | --- | --- | --- | --- | --- | --- | --- | --- | --- | --- | --- |
| 25 | 1.1.4 | **1.4 - Suivi de projet** | 267.65d | 2023-10-12 A | 2024-03-26 A |  | 100% |  | 2023-10-12 | 2024-04-04 | 125.58d |  |  | 132.02h | 132.02h | 2,640.37 | 1,180 | 2,640.37 |
| 26 | 1.1.4.1 | 1.4.1 - Indicateurs de suivi de projet | 4h | 2023-10-12 A | 2023-10-16 A | 24 | 100% |  | 2023-10-12 | 2023-10-16 | 4h |  | D_DA; A_PE | 4h | 4h | 80 | 80 | 80 |
| 27 | 1.1.4.2 | 1.4.2 - Préparation des vidéos - Mi-Semestre | 4h | 2024-03-05 A | 2024-03-08 A | 28 | 100% |  | 2024-02-27 | 2024-02-29 | 3h |  | A_PE; A_PI; K_MO; P_LE | 16h | 16h | 320 | 300 | 320 |
| 28 | 1.1.4.3 | 1.4.3 - Préparation des rapports globaux - Mi-Semestre | 8h | 2024-03-04 A | 2024-03-05 A | 31 | 100% |  | 2024-02-26 | 2024-02-27 | 2h |  | A_PE; A_PI; K_MO; P_LE | 24h | 24h | 480 | 200 | 480 |
| 29 | 1.1.4.4 | 1.4.4 - Préparation des rapports globaux | 29.21h | 2024-03-11 A | 2024-03-26 A | 33 | 100% |  |  |  |  | start no earlier than 2024-03-11 | A_PE; A_PI; D_DA; K_MO; P_LE | 40h | 40h | 800 |  | 800 |
| 30 | 1.1.4.5 | 1.4.6 - Préparation oral 1 | 7h | 2023-10-16 A | 2023-10-26 A | 26 | 100% |  | 2023-10-16 | 2023-10-26 | 5h |  | A_PE; A_PI; D_DA; K_MO; P_LE | 13h | 13h | 260 | 260 | 260 |
| 31 | 1.1.4.6 | 1.4.7 - Préparation oral 2 | 7h | 2023-10-27 A | 2023-11-27 A | 30 | 100% |  | 2023-10-27 | 2023-12-18 | 4.98h |  | A_PE; A_PI; K_MO; P_LE | 17.02h | 17.02h | 340.37 | 300 | 340.37 |
| 32 | 1.1.4.7 | 1.4.8 - GANTT réel - 15/12/2023 | 8h | 2023-10-27 A | 2023-12-08 A | 30 | 100% |  | 2024-02-26 | 2024-04-04 | 2h |  | A_PE | 8h | 8h | 160 | 40 | 160 |
| 33 | 1.1.4.8 | 1.4.9 - GANTT réel | 10h | 2024-03-04 A | 2024-03-06 A | 32 | 100% |  |  |  |  | start no earlier than 2024-01-15 | A_PE | 10h | 10h | 200 |  | 200 |
| 34 | 1.2 | **2 - Développement** | 339.75d | 2023-09-15 A | 2024-04-07 |  | 100% | 2024-04-02 | 2023-09-20 | 2024-02-26 | 112.75d |  |  | 628.61h | 628.61h | 12,572.27 | 7,839.78 | 12,572.27 |
| 35 | 1.2.1 | **2.1 - Conception** | 271.95d | 2023-09-15 A | 2024-03-04 A |  | 100% |  | 2023-09-20 | 2023-12-15 | 62.1d |  |  | 89.41h | 89.41h | 1,788.17 | 1,544.62 | 1,788.17 |
| 36 | 1.2.1.1 | 2.1.1 - Communication (reseaux) | 7h | 2023-11-15 A | 2024-03-04 A | 37, 38 | 100% |  | 2023-11-15 | 2023-12-15 | 7h |  | A_PE; P_LE | 7h | 7h | 140 | 140 | 140 |
| 37 | 1.2.1.2 | 2.1.2 - Architecture | 5h | 2023-11-08 A | 2023-11-10 A | 39 | 100% |  | 2023-11-08 | 2023-11-15 | 10h |  | A_PE; D_DA | 5h | 5h | 100 | 200 | 100 |
| 38 | 1.2.1.3 | 2.1.3 - Architecture Blazor | 10h | 2024-01-08 A | 2024-01-09 A | 37 | 100% |  |  |  |  | start no earlier than 2024-01-01 | A_PE; A_PI | 20h | 20h | 400 |  | 400 |
| 39 | 1.2.1.4 | 2.1.5 - Diagramme de classes PHP | 10h | 2023-10-09 A | 2023-11-03 A | 42 | 100% |  | 2023-10-09 | 2023-11-08 | 10h |  | A_PE; A_PI; D_DA | 11.41h | 11.41h | 228.17 | 404.62 | 228.17 |
| 40 | 1.2.1.5 | 2.1.7 - Maquettes | 8h | 2023-09-25 A | 2023-09-29 A | 5 | 100% |  | 2023-09-25 | 2023-09-29 | 8h |  | A_PI | 8h | 8h | 160 | 160 | 160 |
| 41 | 1.2.1.6 | 2.1.8 - Maquettes Kotlin | 6h | 2023-09-15 A | 2023-09-18 A |  | 100% |  |  |  |  |  | A_PI | 6h | 6h | 120 |  | 120 |
| 42 | 1.2.1.7 | 2.1.9 - MCD & MLD | 12h | 2023-09-29 A | 2023-10-09 A | 40 | 100% |  | 2023-09-29 | 2023-10-09 | 12h |  | D_DA; P_LE; K_MO; A_PI; A_PE | 23h | 23h | 460 | 460 | 460 |
| 43 | 1.2.1.8 | 2.1.10 - Diagramme de cas d'utilisation | 8h | 2023-09-20 A | 2023-09-27 A | 11 | 100% |  | 2023-09-20 | 2023-09-29 | 8h |  | K_MO; A_PE | 8h | 8h | 160 | 160 | 160 |
| 44 | 1.2.1.9 | 2.1.11 - Logo | 1h | 2023-10-05 A | 2023-10-05 A | 11 | 100% |  | 2023-10-05 | 2023-10-05 | 1h |  | D_DA | 1h | 1h | 20 | 20 | 20 |
| 45 | 1.2.2 | **2.2 - Client Web** | 253.5d | 2023-11-15 A | 2024-04-07 |  | 100% | 2024-03-26 | 2023-11-15 | 2024-02-05 | 58.14d |  |  | 57.6h | 57.6h | 1,152 | 2,937.27 | 1,152 |
| 46 | 1.2.2.1 | 2.2.1 - Interface utilisateur client (Vues) WEB | 15h | 2023-11-20 A | 2024-03-11 A | 37 | 100% |  | 2023-11-20 | 2024-01-09 | 15h |  | A_PI | 15h | 15h | 300 | 300 | 300 |
| 47 | 1.2.2.2 | 2.2.2 - Gestion des données client | 15h | 2023-11-15 A | 2023-11-22 A |  | 100% |  | 2023-11-15 | 2023-12-13 | 40h | finish no earlier than 2024-01-12 | A_PE; D_DA; P_LE | 16.1h | 16.1h | 322 | 2,167.27 | 322 |
| 48 | 1.2.2.3 | 2.2.3 - Authentification Web Client | 3h | 2024-02-05 A | 2024-03-26 A | 47 | 100% |  | 2023-12-25 | 2024-02-05 | 3h |  | A_PI; K_MO; D_DA | 3h | 3h | 60 | 60 | 60 |
| 49 | 1.2.2.4 | 2.2.5 - Récupération des données de fréquence cardiaque | 15h | 2023-11-15 A | 2023-11-29 A | 37 | 100% |  | 2023-11-15 | 2023-12-28 | 15h |  | A_PE | 15h | 15h | 300 | 300 | 300 |
| 50 | 1.2.2.5 | 2.2.6 - Définitions des algoritmes d'analyse de la fréquence cardiaque | 3h | 2024-02-26 A | 2024-02-26 A | 37 | 100% |  | 2023-12-15 | 2023-12-22 | 0h | start no earlier than 2024-01-29 | D_DA; A_PE | 3h | 3h | 60 |  | 60 |
| 51 | 1.2.2.6 | 2.2.7 - Mise en place Bootstrap | 3h | 2023-11-15 A | 2023-11-17 A | 37, 43 | 100% |  | 2023-11-15 | 2023-11-17 | 3h |  | A_PI | 3h | 3h | 60 | 60 | 60 |
| 52 | 1.2.2.7 | 2.2.8 - Mise en place talwind | 1.5h | 2023-11-17 A | 2023-11-20 A | 37, 43 | 100% |  | 2023-11-17 | 2023-11-20 | 1.5h |  | A_PI | 1.5h | 1.5h | 30 | 30 | 30 |
| 53 | 1.2.2.8 | 2.2.9 - Mise en place lead PHPStorm | 1h | 2024-02-26 A | 2024-02-26 A | 37, 43 | 100% |  | 2023-12-22 | 2023-12-25 | 1h |  | D_DA | 1h | 1h | 20 | 20 | 20 |

| ID | WBS | Task | Duration | Start | Finish | Predecessors | Complete | Baseline start | Baseline finish | Baseline duration | Constraint | Resources | Work | Actual work | Cost | Baseline cost | Actual cost |
| --- | --- | --- | --- | --- | --- | --- | --- | --- | --- | --- | --- | --- | --- | --- | --- | --- | --- |
| 54 | 1.2.3 | **2.3 - Web admin et monitorin** | 22.75d | 2024-03-06 A | 2024-03-21 A |  | 100% | 2023-11-22 | 2024-01-01 | 27.38d |  |  | 23.77h | 23.77h | 475.33 | 465.57 | 475.33 |
| 55 | 1.2.3.1 | 2.3.1 - Authentification admin et monitoring | 10.5h | 2024-03-14 A | 2024-03-21 A | 38 | 100% | 2023-12-25 | 2024-01-01 | 9.51h | start no earlier than 2024-03-13 | A_PE; D_DA | 13.77h | 13.77h | 275.33 | 265.57 | 275.33 |
| 56 | 1.2.3.2 | 2.3.2 - Interface utilisateur admin (Vues) | 10h | 2024-03-06 A | 2024-03-08 A | 38 | 100% | 2023-11-22 | 2023-12-01 | 10h | start no earlier than 2024-03-06 | A_PI | 10h | 10h | 200 | 200 | 200 |
| 57 | 1.2.4 | **2.4 - Base de données** | 175.65d | 2023-12-13 A | 2024-03-29 A |  | 100% | 2023-12-13 | 2024-02-13 | 43.35d |  |  | 14.55h | 14.55h | 291 | 471 | 291 |
| 58 | 1.2.4.1 | 2.4.1 - Création des tables | 2h | 2023-12-13 A | 2023-12-14 A | 47 | 100% | 2023-12-13 | 2023-12-14 | 2h |  | P_LE | 2h | 2h | 40 | 40 | 40 |
| 59 | 1.2.4.2 | 2.4.2 - Ajout des données | 0.55h | 2023-12-15 A | 2023-12-15 A | 58 | 100% | 2023-12-15 | 2023-12-22 | 1.55h | finish no earlier than 2024-01-19 | A_PE; A_PI | 0.55h | 0.55h | 11 | 31 | 11 |
| 60 | 1.2.4.3 | 2.4.3 - Mise en place d'un système de backup | 12h | 2024-02-26 A | 2024-03-29 A | 58 | 100% | 2023-12-14 | 2024-02-12 | 7.67h |  | A_PE; D_DA | 12h | 12h | 240 | 240 | 240 |
| 61 | 1.2.5 | **2.5 - Serveur et communication de services** | 37.25d | 2023-11-23 A | 2023-12-12 A |  | 100% | 2023-11-15 | 2024-02-09 | 61.6d |  |  | 14h | 14h | 280 | 941.33 | 280 |
| 62 | 1.2.5.1 | 2.5.1 - Authentification serveur PostgreSQL | 4h | 2023-11-23 A | 2023-12-08 A | 36 | 100% | 2023-12-15 | 2024-01-31 | 4h |  | A_PI; K_MO | 4h | 4h | 80 | 80 | 80 |
| 63 | 1.2.5.2 | 2.5.2 - Gestion des données serveur | 8h | 2023-12-11 A | 2023-12-12 A | 62 | 100% | 2024-02-02 | 2024-02-09 | 10.17h | finish no earlier than 2024-01-12 | A_PI; A_PE | 10h | 10h | 200 | 300 | 200 |
| 64 | 1.2.6 | **2.6 - Integration continue et livraison continue (CI/ CD)** | 251.62d | 2023-11-10 A | 2024-04-02 A |  | 100% | 2023-11-15 | 2024-02-26 | 72.66d |  |  | 371.69h | 371.69h | 7,433.77 | 1,480 | 7,433.77 |
| 65 | 1.2.6.1 | 2.6.1 - Tests - PHP | 129.45h | 2023-11-10 A | 2024-03-28 A | 37 | 100% | 2023-11-15 | 2024-01-23 | 40h |  | A_PE; A_PI; D_DA; K_MO; P_LE | 133.6h | 133.6h | 2,672.03 | 960 | 2,672.03 |
| 66 | 1.2.6.2 | 2.6.2 - Tests | 53.36h | 2024-02-12 A | 2024-04-02 A | 65 | 100% |  |  |  | start no earlier than 2024-02-12 | A_PE; A_PI; D_DA; K_MO; P_LE | 150h | 150h | 3,000 |  | 3,000 |
| 67 | 1.2.6.3 | 2.6.3 - Conteneurisation et déploiementc - PHP | 10h | 2024-02-26 A | 2024-03-13 A | 37 | 100% | 2023-11-15 | 2024-01-23 | 8h |  | A_PE; D_DA | 10h | 10h | 200 | 160 | 200 |
| 68 | 1.2.6.4 | 2.6.4 - Conteneurisation et deploiement | 19h | 2024-02-26 A | 2024-03-18 A | 67 | 100% |  |  |  | start no earlier than 2024-02-05 | A_PE; D_DA | 23h | 23h | 460 |  | 460 |
| 69 | 1.2.6.5 | 2.6.5 - Documentations (swagger, schéma, …) PHP | 15.8h | 2024-03-04 A | 2024-04-01 A | 65 | 100% | 2024-01-23 | 2024-02-26 | 6h |  | A_PE; A_PI; D_DA | 24h | 24h | 480 | 360 | 480 |
| 70 | 1.2.6.6 | 2.6.6 - Documentations | 11.09h | 2024-04-01 A | 2024-04-02 A | 69 | 100% |  |  |  |  | D_DA; K_MO; P_LE | 31.09h | 31.09h | 621.73 |  | 621.73 |
| 71 | 1.2.7 | **2.7 - Base de donnée et API** | 28.55d | 2024-02-12 A | 2024-03-04 A |  | 100% |  |  |  |  |  | 17.6h | 17.6h | 352 |  | 352 |
| 72 | 1.2.7.1 | 2.7.1 - Création des Entities | 4h | 2024-02-12 A | 2024-02-13 A | 54 | 100% |  |  |  | start no earlier than 2024-02-05 | A_PE | 4h | 4h | 80 |  | 80 |
| 73 | 1.2.7.2 | 2.7.2 - Liaison des Entities | 7h | 2024-02-13 A | 2024-02-15 A | 72 | 100% |  |  |  |  | A_PE | 7h | 7h | 140 |  | 140 |
| 74 | 1.2.7.3 | 2.7.3 - Création de l'API | 6h | 2024-02-26 A | 2024-02-26 A | 54 | 100% |  |  |  | start no earlier than 2024-02-12 | D_DA | 6h | 6h | 120 |  | 120 |
| 75 | 1.2.7.4 | 2.7.4 - Liaison des Entities et de l'API | 0.3h | 2024-03-04 A | 2024-03-04 A | 73, 74, 36 | 100% |  |  |  | finish no earlier than 2024-04-03 | D_DA; A_PI | 0.6h | 0.6h | 12 |  | 12 |
| 76 | 1.2.8 | **2.8 - Application Mobile** | 76.61d | 2024-02-12 A | 2024-03-30 A |  | 100% |  |  |  |  |  | 40h | 40h | 800 |  | 800 |
| 77 | 1.2.8.1 | 2.8.1 - Définitions de l'architecture Kotlin | 8h | 2024-02-12 A | 2024-03-25 A | 54 | 100% |  |  |  | start no earlier than 2024-02-05 | A_PI; D_DA | 8h | 8h | 160 |  | 160 |
| 78 | 1.2.8.2 | 2.8.2 - Interface utilisateur (vues) Mobile | 1d | 2024-03-25 A | 2024-03-26 A | 77 | 100% |  |  |  |  | A_PI | 2h | 2h | 40 |  | 40 |
| 79 | 1.2.8.3 | 2.8.3 - Diagramme de classes Kotlin | 8h | 2024-03-04 A | 2024-03-26 A | 77 | 100% |  |  |  |  | A_PE; A_PI; D_DA; K_MO; P_LE | 24h | 24h | 480 |  | 480 |
| 80 | 1.2.8.4 | 2.8.4 - Authentification client Mobile | 2d | 2024-03-26 A | 2024-03-30 A | 78, 79 | 100% |  |  |  |  | D_DA; K_MO; P_LE | 6h | 6h | 120 |  | 120 |
